# Exercise_01

How a schedule from MS Project changed from version to version. A marks actual dates.

## Version 1 (saved 2014-08-12, file Exercise_01.mpp)

| ID | WBS | Task | Duration | Start | Finish | Predecessors | Complete | Total float |
| --- | --- | --- | --- | --- | --- | --- | --- | --- |
| 1 |  | Отбор статей | 2d | 2014-10-01 09:00 | 2014-10-02 18:00 |  |  | 8.25d |
| 2 | 2 | **Редактирование** | 15d | 2014-10-03 09:00 | 2014-10-23 18:00 | 1 |  | 0d |
| 3 |  | Ред_Статья 1 | 3d | 2014-10-16 09:00 | 2014-10-20 18:00 |  |  | 2.62d |
| 4 |  | Ред_Статья 2 | 2d | 2014-10-03 09:00 | 2014-10-06 18:00 |  |  | 12.88d |
| 5 |  | Ред_Статья 3 | 6d | 2014-10-03 09:00 | 2014-10-10 18:00 |  |  | 8.25d |
| 6 |  | Ред_Статья 4 | 3d | 2014-10-03 09:00 | 2014-10-07 18:00 |  |  | 11.88d |
| 7 |  | Ред_Статья 5 | 3d | 2014-10-21 09:00 | 2014-10-23 18:00 |  |  | 0d |
| 8 |  | Ред_Статья 6 | 4d | 2014-10-10 09:00 | 2014-10-15 18:00 |  |  | 5.62d |
| 9 |  | Ред_Статья 7 | 5d | 2014-10-03 09:00 | 2014-10-09 18:00 |  |  | 9d |
| 10 |  | Ред_Статья 8 | 2d | 2014-10-08 09:00 | 2014-10-09 18:00 |  |  | 9.88d |
| 11 |  | Ред_Статья 9 | 1d | 2014-10-10 09:00 | 2014-10-10 18:00 |  |  | 9d |
| 12 |  | Ред_Статья 10 | 4d | 2014-10-13 09:00 | 2014-10-16 18:00 |  |  | 4.75d |
| 13 | 3 | **Корректура** | 13.25d | 2014-10-07 09:00 | 2014-10-24 11:00 |  |  | 0d |
| 14 |  | Корр_Статья 1 | 5h | 2014-10-21 09:00 | 2014-10-21 15:00 | 3 |  | 2.62d |
| 15 |  | Корр_Статья 2 | 3h | 2014-10-07 09:00 | 2014-10-07 12:00 | 4 |  | 12.88d |
| 16 |  | Корр_Статья 3 | 6h | 2014-10-13 12:00 | 2014-10-14 10:00 | 5 |  | 8.12d |
| 17 |  | Корр_Статья 4 | 3h | 2014-10-08 09:00 | 2014-10-08 12:00 | 6 |  | 11.88d |
| 18 |  | Корр_Статья 5 | 2h | 2014-10-24 09:00 | 2014-10-24 11:00 | 7 |  | 0d |
| 19 |  | Корр_Статья 6 | 5h | 2014-10-16 09:00 | 2014-10-16 15:00 | 8 |  | 5.62d |
| 20 |  | Корр_Статья 7 | 6h | 2014-10-10 12:00 | 2014-10-13 12:00 | 9 |  | 8.88d |
| 21 |  | Корр_Статья 8 | 3h | 2014-10-10 09:00 | 2014-10-10 12:00 | 10 |  | 9.88d |
| 22 |  | Корр_Статья 9 | 2h | 2014-10-13 09:00 | 2014-10-13 11:00 | 11 |  | 9d |
| 23 |  | Корр_Статья 10 | 4h | 2014-10-17 09:00 | 2014-10-17 13:00 | 12 |  | 4.75d |
| 24 |  | Авторская коррект | 10d? | 2014-10-24 11:00 | 2014-11-07 11:00 | 13 |  | 0d |
| 25 |  | Верстка | 8d | 2014-11-07 11:00 | 2014-11-19 11:00 | 24 |  | 0d |
| 26 |  | Худ.оформл | 6d | 2014-11-19 11:00 | 2014-11-27 11:00 | 25 |  | 0d |
| 27 |  | Обложка | 11d | 2014-10-01 09:00 | 2014-10-15 18:00 |  |  | 30.25d |
| 28 |  | Печать | 3d | 2014-10-15 13:34 A | 2015-01-13 15:36 | 25, 26, 27 | 10% | 0d |

## Version 2 (saved 2014-08-12, file Exercise_01_2003.mpp)

Last finish 2015-01-13 → 2014-11-27 (-47d).

Removed: 8 Ред_Статья 6; 9 Ред_Статья 7; 10 Ред_Статья 8; 11 Ред_Статья 9; 12 Ред_Статья 10; 19 Корр_Статья 6; 20 Корр_Статья 7; 21 Корр_Статья 8; 22 Корр_Статья 9; 23 Корр_Статья 10; 28 Печать

Changed:

| ID | Task | Start | Finish | Other |
| --- | --- | --- | --- | --- |
| 1 | Отбор статей | 2014-10-01 09:00 → 2014-10-01 | 2014-10-02 18:00 → 2014-10-02 | baseline start 2014-10-01 09:00 → 2014-10-01; baseline finish 2014-10-02 18:00 → 2014-10-02 |
| 2 | **Редактирование** | 2014-10-03 09:00 → 2014-10-03 | 2014-10-23 18:00 → 2014-10-23 | baseline start 2014-10-03 09:00 → 2014-10-03; baseline finish 2014-10-10 18:00 → 2014-10-10 |
| 3 | Ред_Статья 1 | 2014-10-16 09:00 → 2014-10-16 | 2014-10-20 18:00 → 2014-10-20 | baseline start 2014-10-03 09:00 → 2014-10-03; baseline finish 2014-10-07 18:00 → 2014-10-07 |
| 4 | Ред_Статья 2 | 2014-10-03 09:00 → 2014-10-03 | 2014-10-06 18:00 → 2014-10-06 | baseline start 2014-10-03 09:00 → 2014-10-03; baseline finish 2014-10-06 18:00 → 2014-10-06 |
| 5 | Ред_Статья 3 | 2014-10-03 09:00 → 2014-10-03 | 2014-10-10 18:00 → 2014-10-10 | baseline start 2014-10-03 09:00 → 2014-10-03; baseline finish 2014-10-10 18:00 → 2014-10-10 |
| 6 | Ред_Статья 4 | 2014-10-03 09:00 → 2014-10-03 | 2014-10-07 18:00 → 2014-10-07 | baseline start 2014-10-03 09:00 → 2014-10-03; baseline finish 2014-10-07 18:00 → 2014-10-07 |
| 7 | Ред_Статья 5 | 2014-10-21 09:00 → 2014-10-21 | 2014-10-23 18:00 → 2014-10-23 | baseline start 2014-10-03 09:00 → 2014-10-03; baseline finish 2014-10-07 18:00 → 2014-10-07 |
| 8 | **Корректура** | 2014-10-07 09:00 → 2014-10-07 | 2014-10-24 11:00 → 2014-10-24 | baseline start 2014-10-06 09:00 → 2014-10-06; baseline finish 2014-10-13 16:00 → 2014-10-13 |
| 9 | Корр_Статья 1 | 2014-10-21 09:00 → 2014-10-21 | 2014-10-21 15:00 → 2014-10-21 | baseline start 2014-10-08 09:00 → 2014-10-08; baseline finish 2014-10-08 15:00 → 2014-10-08 |
| 10 | Корр_Статья 2 | 2014-10-07 09:00 → 2014-10-07 | 2014-10-07 12:00 → 2014-10-07 | baseline start 2014-10-07 09:00 → 2014-10-07; baseline finish 2014-10-07 12:00 → 2014-10-07 |
| 11 | Корр_Статья 3 | 2014-10-13 12:00 → 2014-10-13 | 2014-10-14 10:00 → 2014-10-14 | baseline start 2014-10-13 09:00 → 2014-10-13; baseline finish 2014-10-13 16:00 → 2014-10-13 |
| 12 | Корр_Статья 4 | 2014-10-08 09:00 → 2014-10-08 | 2014-10-08 12:00 → 2014-10-08 | baseline start 2014-10-08 09:00 → 2014-10-08; baseline finish 2014-10-08 12:00 → 2014-10-08 |
| 13 | Корр_Статья 5 | 2014-10-24 09:00 → 2014-10-24 | 2014-10-24 11:00 → 2014-10-24 | baseline start 2014-10-08 09:00 → 2014-10-08; baseline finish 2014-10-08 11:00 → 2014-10-08 |
| 14 | Авторская коррект | 2014-10-24 11:00 → 2014-10-24 | 2014-11-07 11:00 → 2014-11-07 | baseline start 2014-10-13 16:00 → 2014-10-13; baseline finish 2014-10-27 16:00 → 2014-10-27 |
| 15 | Верстка | 2014-11-07 11:00 → 2014-11-07 | 2014-11-19 11:00 → 2014-11-19 | baseline start 2014-10-27 16:00 → 2014-10-27; baseline finish 2014-11-06 16:00 → 2014-11-06 |
| 16 | Худ.оформл | 2014-11-19 11:00 → 2014-11-19 | 2014-11-27 11:00 → 2014-11-27 | baseline start 2014-11-06 16:00 → 2014-11-06; baseline finish 2014-11-14 16:00 → 2014-11-14 |
| 17 | Обложка | 2014-10-01 09:00 → 2014-10-01 | 2014-10-15 18:00 → 2014-10-15 | baseline start 2014-10-01 09:00 → 2014-10-01; baseline finish 2014-10-15 18:00 → 2014-10-15 |
